Schedule from MS Project MPX, 2007-01-02 to 2007-07-27.

## Calendars

- Standard: Mon-Fri 08:00-12:00, 13:00-17:00; Sat-Sun off.

## Resources

| Resource |
| --- |
| Dudek |
| Fan |
| Williamson |
| Gettelfinger |
| Gettlefinger |
| Brooks |
| Viola |

## Schedule

| ID | WBS | Task | Duration | Start | Finish | Predecessors | Baseline start | Baseline finish | Baseline duration | Constraint | Resources |
| --- | --- | --- | --- | --- | --- | --- | --- | --- | --- | --- | --- |
| 1 | 1 | **Bladder tests** | 56.00d | 2007-01-22 | 2007-04-09 |  | 2007-01-22 | 2007-04-09 | 56.00d |  |  |
| 2 | 1.1 | Define test plan. Set up test fixture. Order bladders, fill materials, and candidate epoxies for bladder tests. | 10.00d | 2007-01-22 | 2007-02-02 |  | 2007-01-22 | 2007-02-02 | 10.00d | start no earlier than 2007-01-22 | Dudek |
| 3 | 1.2 | Perform bench test of Teflon bladder to determine properties | 5.00d | 2007-02-05 | 2007-02-09 | 2 | 2007-02-05 | 2007-02-09 | 5.00d | start no earlier than 2007-01-12 | Dudek |
| 4 | 1.3 | Procure/fab prototype bladder for C-C installation | 10.00d | 2007-02-12 | 2007-02-23 | 3 | 2007-02-12 | 2007-02-23 | 10.00d |  | Dudek |
| 5 | 1.4 | Review structural analyses to determine bladder performance requirements. Verify adequate performance of Teflon bladder. | 5.00d | 2007-02-12 | 2007-02-16 | 3 | 2007-02-12 | 2007-02-16 | 5.00d | start no earlier than 2007-01-22 | Fan |
| 6 | 1.5 | Determine if ""one size fits all"". Develop procurement drawings for bladder. | 10.00d | 2007-01-22 | 2007-02-02 |  | 2007-01-22 | 2007-02-02 | 10.00d | start no earlier than 2007-01-22 | Williamson |
| 7 | 1.6 | Conduct FDR of bladder design | 1.00d | 2007-02-19 | 2007-02-19 | 6, 5 | 2007-02-19 | 2007-02-19 | 1.00d |  | Williamson |
| 8 | 1.7 | Resolve FDR issues, release procurement drawings for fabrication | 5.00d | 2007-02-20 | 2007-02-26 | 7 | 2007-02-20 | 2007-02-26 | 5.00d |  | Williamson |
| 9 | 1.8 | Procure bladders | 30.00d | 2007-02-27 | 2007-04-09 | 8 | 2007-02-27 | 2007-04-09 | 30.00d |  | Dudek |
| 11 | 2 | **Coefficient of friction (COF) tests** | 45.00d | 2007-01-02 | 2007-03-05 |  | 2007-01-02 | 2007-03-05 | 45.00d |  |  |
| 12 | 2.1 | Order candidate materials for screening tests. Perform screening tests. | 15.00d | 2007-01-02 | 2007-01-22 |  | 2007-01-02 | 2007-01-22 | 15.00d | start no earlier than 2007-01-02 | Gettelfinger |
| 13 | 2.2 | Pick surface treatment for standard shims. Prepare shims for additional testing. | 5.00d | 2007-01-23 | 2007-01-29 | 12 | 2007-01-23 | 2007-01-29 | 5.00d | start no earlier than 2007-01-02 | Gettelfinger |
| 14 | 2.3 | Perform additional COF tests (LN2 testing, cyclic tests, COF versus normal pressure, etc) for standard shims | 10.00d | 2007-01-30 | 2007-02-12 | 13 | 2007-01-30 | 2007-02-12 | 10.00d |  | Gettelfinger |
| 15 | 2.4 | Pick and order material for high COF shims. | 10.00d | 2007-01-23 | 2007-02-05 | 12 | 2007-01-23 | 2007-02-05 | 10.00d | start no earlier than 2007-01-02 | Gettlefinger |
| 16 | 2.5 | Perform additional COF tests (LN2 testing, cyclic tests, COF versus normal pressure, etc) for high COF shims | 10.00d | 2007-02-13 | 2007-02-26 | 15, 14 | 2007-02-13 | 2007-02-26 | 10.00d |  | Gettelfinger |
| 17 | 2.6 | Document and conduct review of test results | 5.00d | 2007-02-27 | 2007-03-05 | 16 | 2007-02-27 | 2007-03-05 | 5.00d |  | Gettlefinger |
| 19 | 4 | **Tension tests of a bolted joint** | 85.00d | 2007-01-22 | 2007-05-18 |  | 2007-01-22 | 2007-05-18 | 85.00d |  |  |
| 20 | 4.1 | Develop drawings of prototypical bolted joint for tapped hole and through hole joints | 5.00d | 2007-01-22 | 2007-01-26 |  | 2007-01-22 | 2007-01-26 | 5.00d | start no earlier than 2007-01-22 | Williamson |
| 21 | 4.2 | Procure/fab parts for joint test | 15.00d | 2007-01-29 | 2007-02-16 | 20 | 2007-01-29 | 2007-02-16 | 15.00d |  | Dudek |
| 22 | 4.3 | Pick candidate concepts for tightening nuts | 5.00d | 2007-01-22 | 2007-01-26 |  | 2007-01-22 | 2007-01-26 | 5.00d | start no earlier than 2007-01-22 | Dudek |
| 23 | 4.4 | Procure tools for tightening nuts | 15.00d | 2007-01-29 | 2007-02-16 | 22 | 2007-01-29 | 2007-02-16 | 15.00d |  | Dudek |
| 24 | 4.5 | Develop design of test fixture and instrumentation | 5.00d | 2007-01-22 | 2007-01-26 |  | 2007-01-22 | 2007-01-26 | 5.00d | start no earlier than 2007-01-22 | Gettelfinger |
| 25 | 4.6 | Set up test fixture and equipment | 15.00d | 2007-01-29 | 2007-02-16 | 24 | 2007-01-29 | 2007-02-16 | 15.00d |  | Gettelfinger |
| 26 | 4.7 | Measure joint deflection v. preload (include UT or SG measurement of bolt tension) | 3.00d | 2007-02-19 | 2007-02-21 | 25 | 2007-02-19 | 2007-02-21 | 3.00d |  | Gettlefinger |
| 27 | 4.8 | Measure joint deflection v. temperature (including candidate washer materials) | 3.00d | 2007-02-22 | 2007-02-26 | 26 | 2007-02-22 | 2007-02-26 | 3.00d |  | Gettelfinger |
| 28 | 4.9 | Measure joint relaxation v. time (days) | 20.00d | 2007-02-27 | 2007-03-26 | 27 | 2007-02-27 | 2007-03-26 | 20.00d |  | Gettlefinger |
| 29 | 4.10 | Measure joint relaxation v. cooldown cycles | 4.00d | 2007-02-27 | 2007-03-02 | 27 | 2007-02-27 | 2007-03-02 | 4.00d |  | Gettlefinger |
| 30 | 4.11 | Perform pullout tests for tapped holes | 4.00d | 2007-03-27 | 2007-03-30 | 29, 28 | 2007-03-27 | 2007-03-30 | 4.00d |  | Gettlefinger |
| 31 | 4.12 | Document and conduct review of test results | 5.00d | 2007-04-02 | 2007-04-06 | 30, 33 | 2007-04-02 | 2007-04-06 | 5.00d |  | Gettelfinger |
| 32 | 4.13 | Procure studs, nuts, and washers | 30.00d | 2007-04-09 | 2007-05-18 | 31 | 2007-04-09 | 2007-05-18 | 30.00d |  | Dudek |
| 33 | 4.14 | Perform analyses to determine geometry and location of high COF shims and placement of new studs | 10.00d | 2007-01-22 | 2007-02-02 |  | 2007-01-22 | 2007-02-02 | 10.00d | start no earlier than 2007-01-22 | Brooks |

| ID | WBS | Task | Duration | Start | Finish | Predecessors | Baseline start | Baseline finish | Baseline duration | Constraint | Resources |
| --- | --- | --- | --- | --- | --- | --- | --- | --- | --- | --- | --- |
| 35 | 5 | **Bushing tests** | 65.00d | 2007-01-22 | 2007-04-20 |  | 2007-01-22 | 2007-04-20 | 65.00d |  |  |
| 36 | 5.1 | Indentify candidate schemes for getting a bushing the fits tightly into the hole and around a stud. Prepare sketches. | 5.00d | 2007-01-22 | 2007-01-26 |  | 2007-01-22 | 2007-01-26 | 5.00d | start no earlier than 2007-01-22 | Williamson |
| 37 | 5.2 | Procure bushing materials for tests. Fabricate bushings. | 15.00d | 2007-01-29 | 2007-02-16 | 36 | 2007-01-29 | 2007-02-16 | 15.00d |  | Dudek |
| 38 | 5.3 | Procure tools and materials required for bushing assembly. | 15.00d | 2007-01-29 | 2007-02-16 | 36 | 2007-01-29 | 2007-02-16 | 15.00d |  | Dudek |
| 39 | 5.4 | Perform trial bushing installations (short of gluing them in) on a production coil. | 10.00d | 2007-02-19 | 2007-03-02 | 38, 37 | 2007-02-19 | 2007-03-02 | 10.00d |  | Viola |
| 40 | 5.5 | Document test results. Select bushing configuration. Conduct peer review of test results and bushing selection. | 5.00d | 2007-03-05 | 2007-03-09 | 39 | 2007-03-05 | 2007-03-09 | 5.00d |  | Viola |
| 41 | 5.6 | Procure bushing materials for assembly operations. Fabricate bushings. | 30.00d | 2007-03-12 | 2007-04-20 | 40 | 2007-03-12 | 2007-04-20 | 30.00d |  | Dudek |
| 43 | 6 | **Shear tests of a bolted joint** | 80.00d | 2007-04-09 | 2007-07-27 |  | 2007-04-09 | 2007-07-27 | 80.00d |  |  |
| 44 | 6.1 | Update bolted joint drawings with standard and high COF shims based on friction tests, bushing tests, and tension tests | 10.00d | 2007-04-09 | 2007-04-20 | 40, 31, 17 | 2007-04-09 | 2007-04-20 | 10.00d |  | Williamson |
| 45 | 6.2 | Procure/fab parts for test and initial assembly | 20.00d | 2007-04-23 | 2007-05-18 | 44 | 2007-04-23 | 2007-05-18 | 20.00d |  | Dudek |
| 46 | 6.3 | Set up test fixture | 10.00d | 2007-05-21 | 2007-06-01 | 45 | 2007-05-21 | 2007-06-01 | 10.00d |  | Gettlefinger |
| 47 | 6.4 | Measure joint deflection version shear load. Pull to failure. | 5.00d | 2007-06-04 | 2007-06-08 | 46 | 2007-06-04 | 2007-06-08 | 5.00d |  | Gettelfinger |
| 48 | 6.5 | Document and conduct peer review of test results | 5.00d | 2007-06-11 | 2007-06-15 | 47 | 2007-06-11 | 2007-06-15 | 5.00d |  | Gettelfinger |
| 49 | 6.6 | Procure/fab shims for remaining assembly operations | 30.00d | 2007-06-18 | 2007-07-27 | 48 | 2007-06-18 | 2007-07-27 | 30.00d |  | Dudek |
| 51 | 7 | **Complete design of MC interface hdw** |  |  |  |  |  |  |  |  |  |
| 52 | 7.1 | Establish design criteria for bolted joints |  |  |  |  |  |  |  |  |  |
| 53 | 7.2 | Perform analyses to determine geometry and location of high COF shims and placement of new bolts |  |  |  |  |  |  |  |  |  |
| 54 | 7.3 | Perform structural analyses to establish the adequacy of the proposed design |  |  |  |  |  |  |  |  |  |
| 55 | 7.4 | Develop specs and drawings |  |  |  |  |  |  |  |  |  |
| 56 | 7.5 | Conduct MC interface FDR |  |  |  |  |  |  |  |  |  |
| 57 | 7.6 | Resolve issues, release assembly spec and drawings |  |  |  |  |  |  |  |  |  |
| 59 | 8 | **Complete the design of the tooling and alignment mechanisms** |  |  |  |  |  |  |  |  |  |
| 60 | 8.1 | **Prepare Sta2 for initial operations** |  |  |  |  |  |  |  |  |  |
| 61 | 8.1.1 | Conduct JHA |  |  |  |  |  |  |  |  |  |
| 62 | 8.1.2 | Conduct ACC review of Sta2 |  |  |  |  |  |  |  |  |  |
| 63 | 8.1.3 | Resolve ACC findings |  |  |  |  |  |  |  |  |  |
| 64 | 8.1.4 | Receive RLM authorization for Sta2 initial ops |  |  |  |  |  |  |  |  |  |
| 65 | 8.2 | Perform trial x-y-z alignments on C1-C2. Demonstrate capability to satisfy alignment requirements. |  |  |  |  |  |  |  |  |  |
| 66 | 8.3 | Prototype bladder installation on C1-C2 |  |  |  |  |  |  |  |  |  |
| 67 | 8.4 | Establish alignment mechanisms, metrology equipment complement and positioning requirements, fiducial locations, etc. Conduct peer review. |  |  |  |  |  |  |  |  |  |
| 68 | 8.5 | Procure alignment mechanisms, fiducials, lifting equipment, etc. for assembly operations |  |  |  |  |  |  |  |  |  |

| ID | WBS | Task | Duration | Start | Finish | Baseline start | Baseline finish | Baseline duration |
| --- | --- | --- | --- | --- | --- | --- | --- | --- |
| 70 | 9 | **Finalize preparations for assembly operations** |  |  |  |  |  |  |
| 71 | 9.1 | Document dimensional control plan |  |  |  |  |  |  |
| 72 | 9.2 | Document assembly sequence |  |  |  |  |  |  |
| 73 | 9.3 | Finalize assembly procedure |  |  |  |  |  |  |
| 74 | 9.4 | Establish back office support requirements and data flow |  |  |  |  |  |  |
| 75 | 9.5 | Train technicians in operation of the metrology equipment and measurement procedures |  |  |  |  |  |  |
| 76 | 9.6 | Receive RLM authorization for assembly operations |  |  |  |  |  |  |
| 79 | 10 | **Finalize design of coil assemblies** | 1.00d | 2007-01-11 | 2007-01-11 | 2007-01-11 | 2007-01-11 | 1.00d |
| 80 | 10.1 | FInalize coolant tube supports and terminations |  |  |  |  |  |  |
| 81 | 10.2 | Finalize instrumenation design (TCs and strain gages) |  |  |  |  |  |  |
| 82 | 10.3 | Complete coil assembly spec and dwgs |  |  |  |  |  |  |
| 83 | 10.4 | Conduct FDR. Resolve issues. Release drawings. |  |  |  |  |  |  |
| 84 | 10.5 | Procure hardware required to finish coil assemblies |  |  |  |  |  |  |
| 86 | 12 | **Prepare coils for Sta2 operations** |  |  |  |  |  |  |
| 87 | 12.1 | Update installation procedures |  |  |  |  |  |  |
| 88 | 12.2 | Complete A1 coil |  |  |  |  |  |  |
| 89 | 12.3 | Complete A2 coil |  |  |  |  |  |  |
| 90 | 12.4 | Pre-fit A1-A2, resolve interferences |  |  |  |  |  |  |
| 91 | 12.5 | Complete B1 coil |  |  |  |  |  |  |
| 92 | 12.6 | Pre-fit A1-B1, resolve interferences |  |  |  |  |  |  |
| 93 | 12.7 | Complete C1 coil |  |  |  |  |  |  |
| 94 | 12.8 | Pre-fit B1-C1, resolve interferences |  |  |  |  |  |  |
| 96 | 13 | **Start Sta2 assembly operations** |  |  |  |  |  |  |
| 97 | 13.1 | Assemble/disassemble A1-A2 |  |  |  |  |  |  |
| 98 | 13.2 | Flip A1 |  |  |  |  |  |  |
| 99 | 13.3 | Assemble B1-A1 |  |  |  |  |  |  |
| 100 | 13.4 | Assemble C1-B1 |  |  |  |  |  |  |
| 101 | 13.5 | Remove HP1 (A1-B1-C1) |  |  |  |  |  |  |
